# sampleplan

Schedule from MS Project, 2011-11-24 to 2012-01-25.

## Calendars

- Standard: Mon-Fri 08:00-12:00, 13:00-17:00; Sat-Sun off.

## Resources

| Resource |
| --- |
| CRM |
| Java |
| FLEX |
| QA |
| ProductionSupport |

## Schedule

| ID | WBS | Task | Type | Duration | Start | Finish | Predecessors | Total slack | Free slack | Resources | Work | Story Id |
| --- | --- | --- | --- | --- | --- | --- | --- | --- | --- | --- | --- | --- |
| 1 | 1 | **Development** |  | 22.25d | 2011-11-24 | 2011-12-26 |  | 0d |  |  | 264h |  |
| 2 | 1.1 | Define API |  | 3.75d | 2011-12-08 | 2011-12-20 |  | 3.5d |  | CRM [80%] | 24h | 1412 |
| 3 | 1.2 | Develop backend |  | 5d | 2011-11-24 | 2011-11-30 |  | 13.5d | 0d | CRM [80%] | 32h | 1414 |
| 4 | 1.3 | Define API |  | 3.75d | 2011-12-13 | 2011-12-26 |  | 0d |  | CRM [80%] | 24h | 1412 |
| 5 | 1.4 | Develop backend |  | 5d | 2011-12-01 | 2011-12-07 |  | 12.25d |  | CRM [80%] | 32h | 1414 |
| 6 | 1.5 | Interface to CRM |  | 3.75d | 2011-12-01 | 2011-12-06 | 3 | 13.5d |  | Java [80%] | 24h | 1412 |
| 7 | 1.6 | Define API for UI. |  | 2.5d | 2011-11-24 | 2011-11-28 |  | 4.75d | 0d | Java [80%] | 16h | 1412 |
| 8 | 1.7 | Develop interface to CRM / FLEX |  | 2.5d | 2011-11-28 | 2011-11-30 | 7 | 4.75d | 0d | Java [80%] | 16h | 1412 |
| 9 | 1.8 | Develop UI |  | 6.25d | 2011-12-01 | 2011-12-09 | 8 | 4.75d | 0d | FLEX [80%] | 40h | 1412 |
| 10 | 1.9 | Review with product owner |  | 6.25d | 2011-12-09 | 2011-12-19 | 9 | 4.75d | 0d | FLEX [80%] | 40h | 1412 |
| 11 | 1.10 | Develop story tests |  | 2.5d | 2011-11-24 | 2011-11-28 |  | 19.75d |  | QA [80%] | 16h | 1412 |
| 12 | 2 | Holidays |  | 10d | 2011-12-26 | 2012-01-09 | 1 | 0d |  |  |  |  |
| 13 | 3 | Bug Fixng |  | 6d | 2012-01-09 | 2012-01-17 | 12 | 6.25d |  | CRM [40%]; FLEX [80%]; Java [80%] | 96h |  |
| 14 | 4 | Test story |  | 6.25d | 2012-01-09 | 2012-01-17 | 1, 12 | 0d |  | QA [80%] | 40h | 1412 |
| 15 | 5 | Prepare Handover Docs |  | 5d? | 2011-12-09 | 2011-12-16 | 10SS | 28.25d |  | CRM [20%]; FLEX [20%]; Java [20%] | 24h |  |
| 16 | 6 | Test/Bug fix On Live |  | 5d | 2012-01-17 | 2012-01-24 | 14 | 0d |  | CRM [80%]; FLEX [80%]; Java [80%]; QA [80%] | 51.2h |  |
| 17 | 7 | Move To Live |  | 1d? | 2012-01-24 | 2012-01-25 | 16 | 0d |  | ProductionSupport [80%] | 6.4h |  |
| 20 | 8 | **Milestones** |  | 44.5d | 2011-11-24 | 2012-01-25 |  | 0d |  |  |  |  |
| 21 | 8.1 | Development Started | milestone | 0d | 2011-11-24 | 2011-11-24 |  | 44.5d |  |  |  |  |
| 22 | 8.2 | Story Code Complete | milestone | 0d | 2011-12-26 | 2011-12-26 | 1 | 22.25d |  |  |  |  |
| 23 | 8.3 | Story Accepted | milestone | 0d | 2012-01-17 | 2012-01-17 | 14 | 6d |  |  |  |  |
| 24 | 8.4 | Go Live | milestone | 0d | 2012-01-25 | 2012-01-25 | 17 | 0d |  |  |  |  |
